# План выполнения работ, ред. 01

Schedule from MS Project, 2019-11-14 to 2020-02-04, costs in р., A marks actual dates.
***

## Calendars

- Стандартный: Mon-Fri 09:00-13:00, 14:00-18:00; Sat-Sun off.

## Resources

| Resource | Rate |
| --- | --- |
| Руководитель проекта | 1000 |
| Разработчик системы ORACLE 1 | 700 |
| Разработчик системы WEB | 800 |
| Разработчик контроллеров | 800 |
| Сотрудник исполнителя |  |
| Технический специалист | 400 |
| Специалист по внедрению | 500 |
| Разработчик документации | 250 |
| Архитектор системы, | 800 |
| Разработчик системы Отчетов | 500 |
| Разработчик системы ORACLE 2 | 700 |

## Schedule

| ID | WBS | Task | Duration | Start | Finish | Predecessors | Complete | Total slack | Free slack | Constraint | Resources | Work | Actual work | Cost | Actual cost |
| --- | --- | --- | --- | --- | --- | --- | --- | --- | --- | --- | --- | --- | --- | --- | --- |
| 1 | 1 | **Разработка автоматизированной информационной системы «Астерион»** | 57d | 2019-11-14 | 2020-01-31 |  |  |  |  |  |  | 916h |  | 671,600 | 494,800 |
| 2 | 1.1 | **Этап 1. Проектирование БД и интерфейсов** | 10d | 2019-11-18 | 2019-11-29 |  |  | -2d | 0d |  |  | 160h |  | 128,000 | 128,000 |
| 3 | 1.1.1 | Установка сервисов CARABI и БД Asterion | 1d | 2019-11-18 A | 2019-11-18 A |  | 100% |  |  | start no earlier than 2019-11-18 | Архитектор системы, | 8h | 8h | 6,400 | 6,400 |
| 4 | 1.1.2 | Настройка архитектуры и модификация архитектуры БД | 5d | 2019-11-19 A | 2019-11-25 A | 3 | 100% |  |  |  | Архитектор системы, | 40h | 40h | 32,000 | 32,000 |
| 5 | 1.1.3 | Экран1. VUE.JS диаграммма ганта изделия. Проектирование и согласование | 5d | 2019-11-18 A | 2019-11-22 A |  | 100% |  |  | start no earlier than 2019-11-18 | Разработчик системы WEB | 40h | 40h | 32,000 | 32,000 |
| 6 | 1.1.4 | Экран2. VUE.JS таймлайн Производственного расписания. Проектирование и согласование | 5d | 2019-11-25 A | 2019-11-29 A | 5 | 100% |  |  |  | Разработчик системы WEB | 40h | 40h | 32,000 | 32,000 |
| 7 | 1.1.5 | Доработка алгоритма расстановки расписания и объединения работ. Согласование | 4d | 2019-11-18 A | 2019-11-21 A |  | 100% |  |  | start no earlier than 2019-11-18 | Архитектор системы, | 32h | 32h | 25,600 | 25,600 |
| 8 | 1.2 | **Этап 2. Производственное планирование** | 16d | 2019-12-02 | 2019-12-23 |  |  | -2d | 0d |  |  | 348h |  | 262,800 | 240,400 |
| 9 | 1.2.1 | **Инициализация продукта** | 6d | 2019-12-02 | 2019-12-09 |  |  | 39d |  |  |  | 48h |  | 38,400 | 38,400 |
| 10 | 1.2.1.1 | Настройка и загрузка номенклатурного справочника материалов | 3d | 2019-12-02 A | 2019-12-04 A | 6 | 100% |  |  |  | Архитектор системы, | 24h | 24h | 19,200 | 19,200 |
| 11 | 1.2.1.2 | Наполнение производственных справочников - Операции, Рабочие центры, список типовых работ | 3d | 2019-12-05 A | 2019-12-09 A | 10 | 100% |  |  |  | Архитектор системы, | 24h | 24h | 19,200 | 19,200 |
| 12 | 1.2.2 | **БП. База продукции и комплектаций** | 8d | 2019-12-02 | 2019-12-11 |  |  | 37d |  |  |  | 64h |  | 46,400 | 46,400 |
| 13 | 1.2.2.1 | Создание справочника продукции и Справочника комплектаций | 2d | 2019-12-02 A | 2019-12-03 A | 6 | 100% |  |  |  | Архитектор системы, | 16h | 16h | 12,800 | 12,800 |
| 14 | 1.2.2.2 | Функциональность создания комплектации изделия | 3d | 2019-12-04 A | 2019-12-06 A | 13 | 100% |  |  |  | Разработчик системы ORACLE 1 | 24h | 24h | 16,800 | 16,800 |
| 15 | 1.2.2.3 | Функциональность Загрузка спецификации изделия | 2d | 2019-12-09 A | 2019-12-10 A | 14 | 100% |  |  |  | Разработчик системы ORACLE 1 | 16h | 16h | 11,200 | 11,200 |
| 16 | 1.2.2.4 | Функциональность поддержки версий комплектации, лист изменений | 1d | 2019-12-11 A | 2019-12-11 A | 15 | 100% |  |  |  | Разработчик системы ORACLE 1 | 8h | 8h | 5,600 | 5,600 |
| 17 | 1.2.3 | **БП Формирование заказа на производство. Констркутор** | 2.5d | 2019-12-02 | 2019-12-04 |  |  | -2d | 0d |  |  | 20h |  | 14,000 | 14,000 |
| 18 | 1.2.3.1 | Функциональность создания Заказа на производство. Предварительный расчет времени | 1d | 2019-12-02 A | 2019-12-02 A | 6 | 100% |  |  | start no earlier than 2019-11-12 | Разработчик системы ORACLE 2 | 8h | 8h | 5,600 | 5,600 |
| 19 | 1.2.3.2 | Функциональность Загрузка заказа из EXCEL 1c | 1d | 2019-12-03 A | 2019-12-03 A | 18 | 100% |  |  |  | Разработчик системы ORACLE 2 | 8h | 8h | 5,600 | 5,600 |
| 20 | 1.2.3.3 | Функциональность создания и сохранения новой комплектации | 0.5d | 2019-12-04 A | 2019-12-04 A | 19 | 100% |  |  |  | Разработчик системы ORACLE 2 | 4h | 4h | 2,800 | 2,800 |
| 21 | 1.2.4 | **БП Формирование заказа на производство. Технолог** | 10d | 2019-12-03 | 2019-12-16 |  |  | 28d |  |  |  | 80h |  | 62,400 | 62,400 |
| 22 | 1.2.4.1 | Функциональность формирования перечня производственных работ | 1d | 2019-12-03 A | 2019-12-03 A | 18 | 100% |  |  |  | Архитектор системы, | 8h | 8h | 6,400 | 6,400 |
| 23 | 1.2.4.2 | Переработка алгоритма расстановки работ по рабочим центрам | 2d | 2019-12-04 A | 2019-12-05 A | 22 | 100% |  |  |  | Разработчик системы ORACLE 1 | 16h | 16h | 11,200 | 11,200 |
| 24 | 1.2.4.3 | Разработка диаграммы ганта работ по изделиям | 7d | 2019-12-06 A | 2019-12-16 A | 23 | 100% |  |  |  | Разработчик системы WEB | 56h | 56h | 44,800 | 44,800 |

| ID | WBS | Task | Duration | Start | Finish | Predecessors | Complete | Total slack | Free slack | Constraint | Resources | Work | Actual work | Cost | Actual cost |
| --- | --- | --- | --- | --- | --- | --- | --- | --- | --- | --- | --- | --- | --- | --- | --- |
| 25 | 1.2.5 | **БП. Производственное планирование** | 15d | 2019-12-03 | 2019-12-23 |  |  | -2d | 0d |  |  | 136h |  | 101,600 | 79,200 |
| 26 | 1.2.5.1 | Функциональность формирования производственных нарядов | 1d | 2019-12-17 A | 2019-12-17 A | 24 | 100% |  |  |  | Разработчик системы ORACLE 1 | 8h | 8h | 5,600 | 5,600 |
| 27 | 1.2.5.2 | Доработка программы производственного планирования работ по рабочим центрам | 4d | 2019-12-18 A | 2019-12-23 A | 26 | 100% |  |  |  | Разработчик системы ORACLE 1 | 32h | 32h | 22,400 | 22,400 |
| 28 | 1.2.5.3 | Разработка интерфейса производственного расписания | 8d | 2019-12-03 A | 2019-12-12 A | 18 | 100% |  |  |  | Разработчик системы WEB | 64h | 64h | 51,200 | 51,200 |
| 29 | 1.2.5.4 | Функциональность регистрации факта выполнения на производственном расписании | 2d | 2019-12-13 | 2019-12-16 | 28 |  | -2d | 0d |  | Разработчик системы ORACLE 1 | 16h |  | 11,200 |  |
| 30 | 1.2.5.5 | Функциональность пересчета производственного расписания по факту и корректировка временных норм | 2d | 2019-12-17 | 2019-12-18 | 29 |  | -2d | 0d |  | Разработчик системы ORACLE 2 | 16h |  | 11,200 |  |
| 31 | 1.3 | **Этап 3. Внедрение производстенного планирования** | 8d | 2019-12-19 | 2019-12-30 |  |  | -2d | 0d |  |  | 72h |  | 36,000 | 24,000 |
| 32 | 1.3.1 | Подготовка и наполнение орг. структуры и загрузка сотрудников. Создание пользователей | 1d | 2019-12-24 A | 2019-12-24 A | 27 | 100% |  |  |  | Специалист по внедрению | 8h | 8h | 4,000 | 4,000 |
| 33 | 1.3.2 | Подготовка и загрузка производственных заказов из 1С | 5d | 2019-12-19 A | 2019-12-25 A | 30 | 100% |  |  |  | Специалист по внедрению | 40h | 40h | 20,000 | 20,000 |
| 34 | 1.3.3 | Проведение презентации по процессам и исправление замечаний | 2d | 2019-12-26 | 2019-12-27 | 33 |  | -2d | 0d |  | Специалист по внедрению | 16h |  | 8,000 |  |
| 35 | 1.3.4 | Обучение ключевых пользователей, тестовая экплуатация | 1d | 2019-12-30 | 2019-12-30 | 34 |  | -2d | 0d |  | Специалист по внедрению | 8h |  | 4,000 |  |
| 36 | 1.4 | **Этап 4. Учет фактов на производстве** | 15d | 2019-12-31 | 2020-01-20 |  |  | -2d | 0d |  |  | 232h |  | 181,600 | 102,400 |
| 37 | 1.4.1 | Экран3. VUE.JS Экран регистрации выполнения работ на рабочем центре. Проектирование и согласование | 5d | 2019-12-31 A | 2020-01-06 A | 35 | 100% |  |  |  | Разработчик системы WEB | 40h | 40h | 32,000 | 32,000 |
| 38 | 1.4.2 | **Экран производственнных нарядов на РЦ** | 12d | 2019-12-31 | 2020-01-15 |  |  | 3d |  |  |  | 72h |  | 56,000 |  |
| 39 | 1.4.2.1 | Функциональность Мониторинг и контроль выполнения субподряда | 1d | 2019-12-31 | 2019-12-31 | 35 |  | 22d | 0d |  | Разработчик системы ORACLE 1 | 8h |  | 5,600 |  |
| 40 | 1.4.2.2 | Функциональность разделения наряда по факту выполнения | 1d | 2020-01-01 | 2020-01-01 | 39 |  | 22d |  |  | Разработчик системы ORACLE 1 | 8h |  | 5,600 |  |
| 41 | 1.4.2.3 | Разработка интерфейса Регистрация факта выполнения работ на РЦ | 7d | 2020-01-07 | 2020-01-15 | 37 |  | -2d | 0d |  | Разработчик системы WEB | 56h |  | 44,800 |  |
| 42 | 1.4.3 | **Разработка считывателя с магнитных карт** | 12d | 2019-12-31 | 2020-01-15 |  |  | 12d |  |  |  | 96h |  | 76,800 | 70,400 |
| 43 | 1.4.3.1 | Разработка контроллера для передачи данных со считывается | 10d | 2019-12-31 A | 2020-01-13 A | 35 | 100% |  |  |  | Разработчик контроллеров | 80h | 80h | 64,000 | 64,000 |
| 44 | 1.4.3.2 | Подключение контроллера к считывателю и тестирование передачи | 1d | 2020-01-14 A | 2020-01-14 A | 43 | 100% |  |  |  | Разработчик контроллеров | 8h | 8h | 6,400 | 6,400 |
| 45 | 1.4.3.3 | Интеграция с Экраном производственных нарядов | 1d | 2020-01-15 | 2020-01-15 | 44 |  | 12d |  |  | Разработчик системы WEB | 8h |  | 6,400 |  |
| 46 | 1.4.4 | **Корректировка складских остатков по факту выполнения** | 3d | 2020-01-16 | 2020-01-20 |  |  | -2d | 0d |  |  | 24h |  | 16,800 |  |
| 47 | 1.4.4.1 | Функциональность постановки выполненных изделий на склад | 1d | 2020-01-16 | 2020-01-16 | 41 |  | -2d | 0d | start no earlier than 2011-06-06 | Разработчик системы ORACLE 2 | 8h |  | 5,600 |  |
| 48 | 1.4.4.2 | Функциональность списания материлов со склада | 2d | 2020-01-17 | 2020-01-20 | 47 |  | 9d |  |  | Разработчик системы ORACLE 2 | 16h |  | 11,200 |  |

| ID | WBS | Task | Duration | Start | Finish | Predecessors | Total slack | Free slack | Resources | Work | Cost |
| --- | --- | --- | --- | --- | --- | --- | --- | --- | --- | --- | --- |
| 49 | 1.5 | **Этап 5. Внедрение Учета фактов на производстве** | 7d | 2020-01-17 | 2020-01-27 |  | -2d | 0d |  | 56h | 28,000 |
| 50 | 1.5.1 | Настройка работы складов материалов и ГП | 1d | 2020-01-17 | 2020-01-17 | 47 | -2d | 0d | Специалист по внедрению | 8h | 4,000 |
| 51 | 1.5.2 | Подготовка и наполненение складких остатков | 2d | 2020-01-20 | 2020-01-21 | 50 | -2d | 0d | Специалист по внедрению | 16h | 8,000 |
| 52 | 1.5.3 | Настройка инвентаризаций по складам | 2d | 2020-01-22 | 2020-01-23 | 51 | -2d | 0d | Специалист по внедрению | 16h | 8,000 |
| 53 | 1.5.4 | Проведение презентации по процессам и исправление замечаний | 1d | 2020-01-24 | 2020-01-24 | 52 | -2d | 0d | Специалист по внедрению | 8h | 4,000 |
| 54 | 1.5.5 | Обучение ключевых пользователей, тестовая экплуатация | 1d | 2020-01-27 | 2020-01-27 | 53 | -2d | 0d | Специалист по внедрению | 8h | 4,000 |
| 55 | 1.6 | **Этап 6. Выгрузка документов в 1С** | 6d | 2020-01-28 | 2020-02-04 |  | -2d | 0d |  | 48h | 35,200 |
| 56 | 1.6.1 | Создание и согласование ТЗ с разработчиком 1С и бухгалтерией | 2d | 2020-01-28 | 2020-01-29 | 54 | -2d | 0d | Архитектор системы, | 16h | 12,800 |
| 57 | 1.6.2 | Изменение и доработка алгоритмов выгрузки документов в 1С | 4d | 2020-01-30 | 2020-02-04 | 56 | -2d | 0d | Разработчик системы ORACLE 1 | 32h | 22,400 |
