# План выполнения работ, ред. 01

Schedule from MS Project, 2011-06-06 to 2020-01-02, costs in р..
***

## Calendars

- Стандартный: Mon-Fri 09:00-13:00, 14:00-18:00; Sat-Sun off.

## Resources

| Resource | Rate |
| --- | --- |
| Руководитель проекта | 1000 |
| Разработчик системы ORACLE 1 | 500 |
| Разработчик системы WEB | 500 |
| Разработчик системы WINDOWS | 500 |
| Сотрудник исполнителя |  |
| Технический специалист | 300 |
| Специалист по внедрению | 400 |
| Разработчик документации | 250 |
| Архитектор системы, |  |
| Разработчик системы Отчетов | 500 |
| Разработчик системы ORACLE 2 | 500 |

## Schedule

| ID | WBS | Task | Duration | Start | Finish | Predecessors | Total slack | Constraint | Resources | Work | Cost |
| --- | --- | --- | --- | --- | --- | --- | --- | --- | --- | --- | --- |
| 1 | 1 | **Разработка автоматизированной информационной системы «Астерион»** | 38d | 2019-11-12 | 2020-01-02 |  |  |  |  | 851.2h | 354,800 |
| 2 | 1.1 | **Этап 1. Автоматизация БП** | 28.9d | 2016-07-06 | 2016-08-15 |  |  |  | Разработчик системы ORACLE 1 | 231.2h | 115,600 |
| 3 | 1.1.1 | **Инициализация продукта** | 1d | 2019-11-12 | 2019-11-12 |  | 0d |  |  |  |  |
| 4 | 1.1.1.1 | Уставновка сервисов CARABI и БД Asterion | 1d | 2019-11-12 | 2019-11-12 |  | 0d |  |  |  |  |
| 5 | 1.1.1.2 | Настройка и загрузка номенклатурного справочника и прайс-листов поставщиков | 1d? | 2019-11-12 | 2019-11-12 |  | 0d |  |  |  |  |
| 6 | 1.1.1.3 | Наполнение производственных справочников - Операции, Рабочие центры, список типовых работ | 1d? | 2019-11-12 | 2019-11-12 |  | 0d |  |  |  |  |
| 7 | 1.1.1.4 | Настройка работы складов | 1d? | 2019-11-12 | 2019-11-12 |  | 0d |  |  |  |  |
| 8 | 1.1.2 | **БП Формирование заказа на производство** | 3d | 2019-11-12 | 2019-11-14 |  | 0d |  |  |  |  |
| 9 | 1.1.2.1 | Функциональность создания Заказа на производство. Предварительный расчет времени | 1d | 2019-11-12 | 2019-11-12 |  | 0d | start no earlier than 2019-11-12 |  |  |  |
| 10 | 1.1.2.2 | Функциональность Загрузка заказа из EXCEL 1c | 0.5d | 2019-11-13 | 2019-11-13 | 9 | 0d |  |  |  |  |
| 11 | 1.1.2.3 | Функциональность по созданию Маршрутных точек | 0.5d | 2019-11-13 | 2019-11-13 | 10 | 0d |  |  |  |  |
| 12 | 1.1.2.4 | Функциональность по отображению WIKI по товару | 1d | 2019-11-14 | 2019-11-14 | 11 | 0d |  |  |  |  |
| 13 | 1.1.3 | **БП Заказ товара поставщику** | 2d | 2019-11-15 | 2019-11-18 | 8 | 0d |  |  |  |  |
| 14 | 1.1.3.1 | Функциональность консолидации заказов от клиентов по товарным группам и формирования Заказа поставщику | 2d | 2019-11-15 | 2019-11-18 |  | 0d |  |  |  |  |
| 15 | 1.1.4 | **БП Подготовка заявки к отгрузке** | 1d | 2019-11-19 | 2019-11-19 | 13 | 0d |  |  |  |  |
| 16 | 1.1.4.1 | Функциональность по корректировке количественных характеристик | 1d | 2011-06-06 | 2011-06-06 |  | 0d | start no earlier than 2011-06-06 |  |  |  |
| 17 | 1.1.5 | **БП Автоматизация БП Прием заказа от поставщика** | 2d | 2019-11-20 | 2019-11-21 | 15 | 0d |  |  |  |  |
| 18 | 1.1.5.1 | Функциональность создания приходной накладной и коррекции остатков | 1d | 2019-11-20 | 2019-11-20 |  | 0d |  |  |  |  |
| 19 | 1.1.5.2 | Функциональность бронирования товара по заказам с учетом корректировок | 1d | 2019-11-21 | 2019-11-21 | 18 | 0d |  |  |  |  |
| 20 | 1.1.6 | **БП Доставка заявки клиентам** | 5.5d | 2019-11-22 | 2019-11-29 | 17 | 0d |  |  |  |  |
| 21 | 1.1.6.1 | Функциональность по подготовке и расчетам Маршрутного листа | 2d | 2019-11-22 | 2019-11-25 |  | 0d |  |  |  |  |
| 22 | 1.1.6.2 | Функциональность для обеспечения уведомлений оператора и водителя об опоздании к точке | 0.5d | 2019-11-26 | 2019-11-26 | 21 | 0d |  |  |  |  |
| 23 | 1.1.6.3 | Функциональность для корректировки данных по маршрутным точкам и ввод причин недоставки и отказов | 2d | 2019-11-26 | 2019-11-28 | 22 | 0d |  |  |  |  |
| 24 | 1.1.6.4 | Функциональность по корректировке Заказов и проведению расходных накладных | 1d | 2019-11-28 | 2019-11-29 | 23 | 0d |  |  |  |  |

| ID | WBS | Task | Duration | Start | Finish | Predecessors | Total slack | Free slack | Resources | Work | Cost |
| --- | --- | --- | --- | --- | --- | --- | --- | --- | --- | --- | --- |
| 25 | 1.1.7 | **БП Взаиморасчеты** | 2.2d | 2019-11-29 | 2019-12-03 | 20 | 0d |  |  |  |  |
| 26 | 1.1.7.1 | Функциональность по созданию платежных требований(счетов) по заказам | 0.5d | 2019-11-29 | 2019-11-29 |  | 0d |  |  |  |  |
| 27 | 1.1.7.2 | Функциональность по вводу денег в кассу по платежным требованиям | 0.2d | 2019-12-02 | 2019-12-02 | 26 | 0d |  |  |  |  |
| 28 | 1.1.7.3 | Функциональность по переводу денег из кассы в кассу | 0.5d | 2019-12-02 | 2019-12-02 | 27 | 0d |  |  |  |  |
| 29 | 1.1.7.4 | Функциональность по списанию баллов клиентов по реализации | 0.5d | 2019-12-02 | 2019-12-03 | 28 | 0d |  |  |  |  |
| 30 | 1.1.7.5 | Функциональность по начислению баллов по промокодам от третьих лиц | 0.5d | 2019-12-03 | 2019-12-03 | 29 | 0d |  |  |  |  |
| 31 | 1.1.8 | **БП Актуализация номенклатуры, прайсов и остатков поставщика** | 4d | 2019-12-03 | 2019-12-09 | 25 | 0d |  |  |  |  |
| 32 | 1.1.8.1 | Функциональность по настройке и загрузке данных по ценам из магазинов. Создание рыночной цены | 3d | 2019-12-03 | 2019-12-06 |  | 0d |  |  |  |  |
| 33 | 1.1.8.2 | Функциональность по созданию WIKI по товарам | 1d | 2019-12-06 | 2019-12-09 | 32 | 0d |  |  |  |  |
| 34 | 1.1.9 | **БП Обработка промокодов** | 2d | 2019-12-09 | 2019-12-11 | 31 | 0d |  |  |  |  |
| 35 | 1.1.9.1 | Функциональность по генерации журнала промокодов. Регистрации передачи промокодов физ. лицу | 1d | 2019-12-09 | 2019-12-10 |  | 0d |  |  |  |  |
| 36 | 1.1.9.2 | Функциональность по отслеживанию акций и прекращению действий промокодов | 1d | 2019-12-10 | 2019-12-11 | 35 | 0d |  |  |  |  |
| 37 | 1.1.10 | **БП Акционные товары** | 1d | 2019-12-11 | 2019-12-12 | 34 | 0d |  |  |  |  |
| 38 | 1.1.10.1 | Функциональность по отслеживанию акционных товаров и прекращению действий акции | 1d | 2019-12-11 | 2019-12-12 |  | 0d |  |  |  |  |
| 39 | 1.1.11 | **БП Вопросы по товарам** | 0.2d | 2019-12-12 | 2019-12-12 | 37 | 0d |  |  |  |  |
| 40 | 1.1.11.1 | Настройка шаблона задач для ответа на вопрос по товару | 0.2d | 2019-12-12 | 2019-12-12 |  | 0d |  |  |  |  |
| 41 | 1.1.12 | **БП Контроль качества обслуживания** | 1.5d | 2019-12-12 | 2019-12-16 | 39 | 0d |  |  |  |  |
| 42 | 1.1.12.1 | Функциональность по автоматическому созданию опроса по клиентам для менеджера | 0.5d | 2019-12-12 | 2019-12-13 |  | 0d |  |  |  |  |
| 43 | 1.1.12.2 | Функциональность по созданию подарочных позиций и организация доступа к подаркам при создании заявки | 1d | 2019-12-13 | 2019-12-16 | 42 | 0d |  |  |  |  |
| 44 | 1.1.13 | **БП Оформление отказа по заказу от клиента** | 1.5d | 2019-12-16 | 2019-12-17 | 41 | 0d |  |  |  |  |
| 45 | 1.1.13.1 | Функциональность по корректировке реализации при отказе | 1d | 2019-12-16 | 2019-12-17 |  | 0d |  |  |  |  |
| 46 | 1.1.13.2 | Функциональность по возврату товара поставщику при отказе | 0.5d | 2019-12-17 | 2019-12-17 | 45 | 0d |  |  |  |  |
| 47 | 1.2 | **Этап 2. Разработка отчетных форм** | 10d | 2019-11-15 | 2019-11-28 | 8 | 0d | 25d | Разработчик системы Отчетов | 80h | 40,000 |
| 48 | 1.2.1 | Корректировка и разработка складских отчетных форм(4 формы) | 2d | 2019-11-15 | 2019-11-18 |  | 0d |  |  |  |  |
| 49 | 1.2.2 | Корректировка и разработка логистических отчетных форм(2 формы) | 3d | 2019-11-19 | 2019-11-21 | 48 | 0d |  |  |  |  |
| 50 | 1.2.3 | Корректировка и разработка отчетных форм по продаже(7 форм) | 5d | 2019-11-22 | 2019-11-28 | 49 | 0d | 25d |  |  |  |

| ID | WBS | Task | Duration | Start | Finish | Predecessors | Total slack | Free slack | Resources | Work | Cost |
| --- | --- | --- | --- | --- | --- | --- | --- | --- | --- | --- | --- |
| 51 | 1.3 | **Этап 3. Разработка экранных форм** | 27d | 2019-11-15 | 2019-12-23 | 8 | 0d | 8d | Разработчик системы WINDOWS | 216h | 108,000 |
| 52 | 1.3.1 | Экран формирования и редактирования Заказа от клиента | 15d | 2019-11-15 | 2019-12-05 |  | 0d |  |  |  |  |
| 53 | 1.3.2 | Экран сканера штрихкодов. Приемка, сборка и проверка по штрих-коду | 12d | 2019-12-06 | 2019-12-23 | 52 | 0d | 8d |  |  |  |
| 54 | 1.4 | **Этап 4. Выгрузка документов в 1С** | 6d | 2019-12-03 | 2019-12-11 | 25 | 0d | 16.3d | Разработчик системы ORACLE 2 | 48h | 24,000 |
| 55 | 1.4.1 | Создание и согласование ТЗ с разработчиком 1С и бухгалтерией | 2d | 2019-12-03 | 2019-12-05 |  | 0d |  |  |  |  |
| 56 | 1.4.2 | Изменение и доработка алгоритмов выгрузки документов в 1С | 4d | 2019-12-05 | 2019-12-11 | 55 | 0d | 16.3d |  |  |  |
| 57 | 1.5 | **Этап 5. Внедрение АИС** | 25.5d | 2019-11-15 | 2019-12-20 | 8 | 0d |  |  | 204h | 60,800 |
| 58 | 1.5.1 | Подготовка и наполнение орг. структуры и загрузка сотрудников. Создание пользователей | 1d | 2019-11-15 | 2019-11-15 |  | 0d |  | Специалист по внедрению | 8h | 3,200 |
| 59 | 1.5.2 | Настройка и загрузка номенклатурного справочника и прайс-листов поставщиков | 0.5d | 2019-11-18 | 2019-11-18 | 58 | 0d |  | Специалист по внедрению | 4h | 1,600 |
| 60 | 1.5.3 | Настройка шаблонов загрузки прайсов от поставщиков | 1d | 2019-11-18 | 2019-11-19 | 59 | 0d |  | Специалист по внедрению | 8h | 3,200 |
| 61 | 1.5.4 | Подготовка и загрузка клиентской базы, контрагентов из 1С | 2d | 2019-11-19 | 2019-11-21 | 60 | 0d |  | Сотрудник исполнителя | 16h |  |
| 62 | 1.5.5 | Подготовка и наполнение логистических справочников | 1d | 2019-11-21 | 2019-11-22 | 61 | 0d |  | Сотрудник исполнителя | 8h |  |
| 63 | 1.5.6 | Подготовка и наполнение складских справочников | 1d | 2019-11-22 | 2019-11-25 | 62 | 0d |  | Сотрудник исполнителя | 8h |  |
| 64 | 1.5.7 | Подготовка и наполненение складких остатков из 1С | 3d | 2019-11-25 | 2019-11-28 | 63 | 0d |  | Специалист по внедрению | 24h | 9,600 |
| 65 | 1.5.8 | Подготовка и настройка финансовых справочников | 2d | 2019-11-28 | 2019-12-02 | 64 | 0d |  | Сотрудник исполнителя | 16h |  |
| 66 | 1.5.9 | Подготовка и загрузка приходных и расходных накладных из 1С | 2d | 2019-12-02 | 2019-12-04 | 65 | 0d |  | Специалист по внедрению | 16h | 6,400 |
| 67 | 1.5.10 | Подготовка и загрузка приходных и расходных кассовых ордеров из 1С | 2d | 2019-12-04 | 2019-12-06 | 66 | 0d |  | Специалист по внедрению | 16h | 6,400 |
| 68 | 1.5.11 | Подготовка и загрузка безналичных платежей из 1С | 2d | 2019-12-06 | 2019-12-10 | 67 | 0d |  | Специалист по внедрению | 16h | 6,400 |
| 69 | 1.5.12 | Настройка телефонии ASTERISK | 2d | 2019-12-10 | 2019-12-12 | 68 | 0d |  | Технический специалист | 16h | 4,800 |
| 70 | 1.5.13 | Установка и настройка мобильных приложений по логистике | 1d | 2019-12-12 | 2019-12-13 | 69 | 0d |  | Специалист по внедрению | 8h | 3,200 |
| 71 | 1.5.14 | Подготовка и загрузка заказов клиентов из 1С | 5d | 2019-12-13 | 2019-12-20 | 70 | 0d | 0.5d | Специалист по внедрению | 40h | 16,000 |
| 72 | 1.6 | **Этап 6. Тестирование и опытная эксплуатация** | 9d | 2019-12-20 | 2020-01-02 | 57 | 0d | 0.5d |  | 72h | 6,400 |
| 73 | 1.6.1 | Проведение презентации по процессам и исправление замечаний | 2d | 2019-12-20 | 2019-12-24 |  | 0d |  | Сотрудник исполнителя | 16h |  |
| 74 | 1.6.2 | Тестовая эскплуатация АИС ключевыми пользователями и исправление замечаний через инциденты | 5d | 2019-12-24 | 2019-12-31 | 73 | 0d |  | Сотрудник исполнителя | 40h |  |
| 75 | 1.6.3 | Миграция данных из 1С и перевод АИС в опытную эксплуатацию | 2d | 2019-12-31 | 2020-01-02 | 74 | 0d | 0.5d | Специалист по внедрению | 16h | 6,400 |
