# План выполнения работ, ред. 01

Schedule from MS Project, 2020-03-24 to 2020-04-22, costs in р..
***

## Calendars

- Стандартный: Mon-Fri 09:00-13:00, 14:00-18:00; Sat-Sun off.

## Resources

| Resource | Rate |
| --- | --- |
| Руководитель проекта | 1000 |
| Разработчик системы ORACLE 1 | 700 |
| Разработчик системы WEB | 800 |
| Разработчик контроллеров | 800 |
| Сотрудник исполнителя |  |
| Технический специалист | 400 |
| Специалист по внедрению | 500 |
| Разработчик документации | 250 |
| Архитектор системы, | 800 |
| Разработчик системы Отчетов | 500 |
| Разработчик системы ORACLE 2 | 700 |

## Schedule

| ID | WBS | Task | Duration | Start | Finish | Predecessors | Total slack | Free slack | Constraint | Resources | Work | Cost |
| --- | --- | --- | --- | --- | --- | --- | --- | --- | --- | --- | --- | --- |
| 1 | 1 | **Внедрение автоматизированной информационной системы «Астерион»** | 22d | 2020-03-24 | 2020-04-22 |  |  |  |  |  | 344h | 218,000 |
| 2 | 1.1 | **БП. Производственное планирование. Доработка и внедрение** | 6d | 2020-03-24 | 2020-03-31 |  | 35d |  |  |  | 104h | 76,800 |
| 3 | 1.1.1 | Функциональность создания комплектации от заказа | 1d | 2020-03-24 | 2020-03-24 |  | 35d | 0d | start no earlier than 2020-03-24 | Разработчик системы ORACLE 1 | 8h | 5,600 |
| 4 | 1.1.2 | Функциональность регистрации факта выполнения на производственном расписании | 2d | 2020-03-25 | 2020-03-26 | 3 | 35d | 0d | start no earlier than 2020-03-24 | Разработчик системы ORACLE 2 | 16h | 11,200 |
| 5 | 1.1.3 | Функциональность пересчета производственного расписания по факту и корректировка временных норм | 2d | 2020-03-25 | 2020-03-26 | 3 | 51d | 0d |  | Разработчик системы ORACLE 1 | 16h | 11,200 |
| 6 | 1.1.4 | График производства по заказам | 2d | 2020-03-25 | 2020-03-26 | 3 | 54d |  |  | Разработчик системы WEB | 16h | 12,800 |
| 7 | 1.1.5 | График производства по исполнителям | 3d | 2020-03-25 | 2020-03-27 | 3 | 53d |  |  | Разработчик системы WEB | 24h | 19,200 |
| 8 | 1.1.6 | Проведение презентации по процессам и исправление замечаний | 2d | 2020-03-27 | 2020-03-30 | 5 | 51d | 0d |  | Архитектор системы, | 16h | 12,800 |
| 9 | 1.1.7 | Обучение ключевых пользователей, тестовая экплуатация | 1d | 2020-03-31 | 2020-03-31 | 8 | 51d |  |  | Специалист по внедрению | 8h | 4,000 |
| 10 | 1.2 | **Экран производственнных нарядов на РЦ** | 11d | 2020-03-27 | 2020-04-10 |  | 35d |  |  |  | 88h | 60,800 |
| 11 | 1.2.1 | Разработка интерфейса Регистрация факта выполнения работ на РЦ | 7d | 2020-03-27 | 2020-04-06 | 4 | 35d | 0d |  | Разработчик системы WEB | 56h | 44,800 |
| 12 | 1.2.2 | Разработка функционала для ввода и печати контрольных листов | 4d | 2020-04-07 | 2020-04-10 | 11 | 43d |  |  | Разработчик системы Отчетов | 32h | 16,000 |
| 13 | 1.3 | **Разработка считывателя с магнитных карт** | 1d | 2020-04-07 | 2020-04-07 |  | 35d |  |  |  | 8h | 3,200 |
| 14 | 1.3.1 | Интеграция с Экраном производственных нарядов | 1d | 2020-04-07 | 2020-04-07 | 11 | 35d | 0d |  | Технический специалист | 8h | 3,200 |
| 15 | 1.4 | **Корректировка складских остатков по факту выполнения** | 3d | 2020-04-07 | 2020-04-09 |  | 41d |  |  |  | 24h | 16,800 |
| 16 | 1.4.1 | Функциональность постановки выполненных изделий на склад | 1d | 2020-04-07 | 2020-04-07 | 11 | 41d | 0d |  | Разработчик системы ORACLE 2 | 8h | 5,600 |
| 17 | 1.4.2 | Функциональность списания материлов со склада | 2d | 2020-04-08 | 2020-04-09 | 16 | 41d | 0d |  | Разработчик системы ORACLE 2 | 16h | 11,200 |
| 18 | 1.5 | **Этап 5. Внедрение Учета фактов на производстве** | 3d | 2020-04-10 | 2020-04-14 |  | 41d |  |  |  | 24h | 12,000 |
| 19 | 1.5.1 | Настройка работы складов материалов и ГП | 1d | 2020-04-10 | 2020-04-10 | 17 | 41d | 0d |  | Специалист по внедрению | 8h | 4,000 |
| 20 | 1.5.2 | Настройка инвентаризаций по складам | 2d | 2020-04-13 | 2020-04-14 | 19 | 41d |  |  | Специалист по внедрению | 16h | 8,000 |
| 21 | 1.6 | **Этап. Закупка** | 4d | 2020-04-08 | 2020-04-13 |  | 35d |  |  |  | 40h | 28,000 |
| 22 | 1.6.1 | Подключение функциональности Заявка на пополнение склада | 1d | 2020-04-08 | 2020-04-08 | 14 | 35d | 0d |  | Разработчик системы ORACLE 1 | 8h | 5,600 |
| 23 | 1.6.2 | Формирование производственного заказа по Заявке на пополнение | 2d | 2020-04-09 | 2020-04-10 | 22 | 35d | 0d |  | Разработчик системы ORACLE 1 | 16h | 11,200 |
| 24 | 1.6.3 | Формирование Заказа поставщикам по заявка на пополнение и потребностям в заказе | 1d | 2020-04-13 | 2020-04-13 | 23 | 42d |  | start no earlier than 2019-11-04 | Разработчик системы ORACLE 1 | 8h | 5,600 |
| 25 | 1.6.4 | Формирование проходных накладных | 1d | 2020-04-13 | 2020-04-13 | 23 | 35d | 0d |  | Разработчик системы ORACLE 1 | 8h | 5,600 |

| ID | WBS | Task | Duration | Start | Finish | Predecessors | Total slack | Free slack | Resources | Work | Cost |
| --- | --- | --- | --- | --- | --- | --- | --- | --- | --- | --- | --- |
| 26 | 1.7 | **Общее тестирование, документирование и запуск** | 7d | 2020-04-14 | 2020-04-22 |  | 35d |  |  | 56h | 20,400 |
| 27 | 1.7.1 | Проведение презентации по процессам и исправление замечаний | 1d | 2020-04-14 | 2020-04-14 | 25 | 35d | 0d | Архитектор системы, | 8h | 6,400 |
| 28 | 1.7.2 | Обучение ключевых пользователей, тестовая экплуатация | 1d | 2020-04-15 | 2020-04-15 | 27 | 35d | 0d | Специалист по внедрению | 8h | 4,000 |
| 29 | 1.7.3 | Документирование системы | 5d | 2020-04-16 | 2020-04-22 | 28 | 35d |  | Разработчик документации | 40h | 10,000 |
